# Cronograma de Obra

Schedule from MS Project, 2022-06-01 to 2022-08-29, costs in S.

## Calendars

- OHLA Chimbote: Mon-Sun 09:00-13:00, 15:00-19:00.

## Schedule

| ID | WBS | Task | Type | Duration | Start | Finish | Predecessors | Total slack | Free slack | Cost |
| --- | --- | --- | --- | --- | --- | --- | --- | --- | --- | --- |
| 1 | 1 | **MEJORAMIENTO DE VÍAS Y ACCESOS EXISTENTES SUBPROYECTOS A3-A4** |  | 90d | 2022-06-01 | 2022-08-29 |  | 0d |  | 3,224,020.1 |
| 2 | 1.1 | INICIO DE OBRA | milestone | 0d | 2022-06-01 | 2022-06-01 |  | 0d |  |  |
| 3 | 1.2 | **TRABAJOS PRELIMINARES** |  | 90d | 2022-06-01 | 2022-08-29 |  | 0d |  | 226,743.24 |
| 4 | 1.2.1 | Movilización de equipos (1ra etapa) |  | 5d | 2022-06-01 | 2022-06-05 | 2 | 0d |  | 33,777.83 |
| 5 | 1.2.2 | Desmovilización de equipos (1ra etapa) |  | 3d | 2022-08-27 | 2022-08-29 | 23FS-2d | 0d |  | 33,777.83 |
| 6 | 1.2.3 | Movilización de equipos (2da etapa) |  | 5d | 2022-06-14 | 2022-06-18 | 14FS-5d | 0d |  | 25,064.49 |
| 7 | 1.2.4 | Desmovilización de equipos (2da etapa) |  | 3d | 2022-08-27 | 2022-08-29 | 22 | 0d |  | 25,064.49 |
| 8 | 1.2.5 | Trazo, Nivelación y Replanteo (1ra etapa) |  | 15d | 2022-06-03 | 2022-06-17 | 4SS+2d | 72d | 0d | 18,564.28 |
| 9 | 1.2.6 | Trazo, Nivelación y Replanteo (2da etapa) |  | 71d | 2022-06-18 | 2022-08-27 | 8 | 2d |  | 90,494.32 |
| 10 | 1.3 | **MOVIMIENTO DE TIERRAS** |  | 84d | 2022-06-06 | 2022-08-28 |  | 0d |  | 2,970,359.28 |
| 11 | 1.3.1 | Roce y Limpieza de Maleza |  | 30d | 2022-06-06 | 2022-07-05 | 4 | 55d |  | 86,488.05 |
| 12 | 1.3.2 | **Mejoramiento de Vías Existentes (1ra etapa)** |  | 13d | 2022-06-06 | 2022-06-18 |  | 0d |  | 372,709.9 |
| 13 | 1.3.2.1 | Vía de acceso a taller de mantenimiento |  | 2d | 2022-06-06 | 2022-06-07 | 4 | 0d |  |  |
| 14 | 1.3.2.2 | Vía de acceso a patio de máquinas - 02 |  | 11d | 2022-06-08 | 2022-06-18 | 13 | 0d |  |  |
| 15 | 1.3.3 | **Mejoramiento de Vías Existentes (2da etapa)** |  | 71d | 2022-06-19 | 2022-08-28 |  | 0d |  | 2,511,161.33 |
| 16 | 1.3.3.1 | Vía de acceso a cantera la Joya |  | 8d | 2022-06-19 | 2022-06-26 | 6, 14 | 0d |  |  |
| 17 | 1.3.3.2 | Vía de acceos a cantera el Principe |  | 7d | 2022-06-27 | 2022-07-03 | 16 | 0d |  |  |
| 18 | 1.3.3.3 | Vía de acceso subproyecto A4 a Cambio Puente |  | 41d | 2022-07-04 | 2022-08-13 | 17 | 0d |  |  |
| 19 | 1.3.3.4 | Vía de acceso a punto de agua F-08 |  | 4d | 2022-07-27 | 2022-07-30 | 18SS+23d | 30d |  |  |
| 20 | 1.3.3.5 | Vía de acceso a DME-13 |  | 2d | 2022-08-02 | 2022-08-03 | 18SS+29d | 26d |  |  |
| 21 | 1.3.3.6 | Vía de acceso a dique 4.2-2-MI |  | 7d | 2022-08-14 | 2022-08-20 | 18 | 0d |  |  |
| 22 | 1.3.3.7 | Vía de acceso a dique 4.2-1-MD |  | 6d | 2022-08-21 | 2022-08-26 | 21 | 0d |  |  |
| 23 | 1.3.3.8 | Vía de acceso empalme Chachapoyas Alto hacía Río Lacramarca |  | 2d | 2022-08-27 | 2022-08-28 | 22 | 0d |  |  |
| 24 | 1.4 | **REPARACIÓN Y REPOSICIÓN DE ESTRUCTURAS** |  | 37d | 2022-06-08 | 2022-07-14 |  | 46d |  | 23,347.6 |
| 25 | 1.4.1 | Reparación de concreto |  | 1d | 2022-06-08 | 2022-06-08 | 13 | 82d |  | 1,435.8 |
| 26 | 1.4.2 | Demolición de estructuras existentes |  | 1d | 2022-07-14 | 2022-07-14 | 27 | 46d |  | 3,698.51 |
| 27 | 1.4.3 | Reposición de pase de agua con tubería HDPE Ø=24 |  | 2d | 2022-07-12 | 2022-07-13 | 18SS+8d | 45d | 0d | 18,213.29 |

| ID | WBS | Task | Type | Duration | Start | Finish | Predecessors | Total slack | Free slack | Cost |
| --- | --- | --- | --- | --- | --- | --- | --- | --- | --- | --- |
| 28 | 1.5 | **CABEZAL DE ENTRADA Y SALIDA** |  | 2d | 2022-07-14 | 2022-07-15 |  | 45d |  | 3,569.98 |
| 29 | 1.5.1 | Concreto 175 Kg/cm2 |  | 1d | 2022-07-15 | 2022-07-15 | 30 | 45d |  | 1,268.28 |
| 30 | 1.5.2 | Encofrado y Desencofrado Normal |  | 1d | 2022-07-14 | 2022-07-14 | 27 | 45d | 0d | 2,301.7 |
| 31 | 1.6 | FIN DE OBRA | milestone | 0d | 2022-08-29 | 2022-08-29 | 5, 7 | 0d |  |  |
